# LCGT Plan Silica RSE Change Suspensions

Schedule from MS Project, 2013-10-01 to 2014-08-31, A marks actual dates.

## Calendars

- 働き詰め: Mon-Fri 08:00-12:00, 13:00-17:00; Sat-Sun 09:00-17:00.

## Resources

| Resource |
| --- |
| ryu |
| seki |
| fab |
| joris |
| aga |
| ono |
| akt |
| tok |
| lun |
| obc |
| miya |

## Schedule

| ID | WBS | Task | Duration | Start | Finish | Predecessors | Complete | Remaining | Total slack | Free slack | Constraint | Resources | Work | Actual work |
| --- | --- | --- | --- | --- | --- | --- | --- | --- | --- | --- | --- | --- | --- | --- |
| 1 | 5 | **VIS** | 335d? | 2013-10-01 A | 2014-08-31 |  | 13% | 292.09d? | 0d |  |  |  | 13272h | 1508.4h |
| 2 | 5.6 | **Type-B SAS test in TAMA** | 335d? | 2013-10-01 A | 2014-08-31 |  | 13% | 292.09d? | 0d |  |  |  | 13272h | 1508.4h |
| 3 | 1.1.1 | **Moving (1)** | 53d? | 2013-10-04 A | 2013-11-25 |  | 63% | 19.63d? | 279d |  |  |  | 1000h | 480h |
| 4 | 1.1.1.1 | Moving preisolator | 41d? | 2013-10-15 A | 2013-11-25 |  | 59% | 17d? | 244d | 0d |  | ryu; seki; tok; ono | 760h | 360h |
| 5 | 1.1.1.2 | Moving bottom filter | 1d? | 2013-10-08 A | 2013-10-08 A |  | 100% |  |  |  | finish no earlier than 2012-10-08 | ryu | 8h | 8h |
| 6 | 1.1.1.3 | Moving West End TAMA-SAS | 9d? | 2013-10-04 A | 2013-10-14 A |  | 100% |  |  |  | finish no earlier than 2012-10-10 | fab; ryu | 112h | 112h |
| 7 | 1.1.1.4 | Cleaning 20m lab | 3d? | 2013-11-05 | 2013-11-07 |  |  |  | 295d |  | start no earlier than 2013-11-05 | fab; joris; aga; ryu; seki | 120h |  |
| 8 | 1.1.2 | **Moving (2)** | 12d? | 2014-02-17 | 2014-02-28 |  |  |  | 182d |  |  |  | 272h |  |
| 9 | 1.1.2.1 | Moving standard filter and damper | 12d? | 2014-02-17 | 2014-02-28 | 12 |  |  | 182d |  | start no earlier than 2014-02-17 | ono; ryu; seki | 272h |  |
| 10 | 1.1.3 | **Test in ICRR** | 124d? | 2013-10-14 A | 2014-02-14 |  | 11% | 110.3d? | 198d |  |  |  | 2184h | 267.2h |
| 11 | 1.1.3.1 | Standard filter magic wand tuning | 59d? | 2013-10-14 A | 2013-12-17 |  | 23% | 45.5d? | 257d |  | finish no earlier than 2012-11-30 | ono; seki | 752h | 188h |
| 12 | 1.1.3.2 | Torsion mode damping test | 108d? | 2013-10-28 A | 2014-02-14 |  | 5% | 103.05d? | 184d | 2d | finish no earlier than 2014-02-14 | ono; seki | 1432h | 79.2h |
| 13 | 1.1.4 | **Outer frame test** | 77d? | 2013-10-01 A | 2013-12-16 |  | 56% | 34.03d? | 258d |  |  |  | 448h | 223.2h |
| 14 | 1.1.4.1 | Hammering test without load | 31d? | 2013-10-01 A | 2013-10-31 |  | 90% | 3.1d? | 304d |  | finish no earlier than 2012-10-31 | lun | 248h | 223.2h |
| 15 | 1.1.4.2 | Hammering test with preisolator | 9d? | 2013-11-26 | 2013-12-04 | 4 |  |  | 162d | 0d | start no earlier than 2012-11-14 | lun | 72h |  |
| 16 | 1.1.4.3 | Frame seismic noise measurement | 10d? | 2013-12-05 | 2013-12-16 | 15 |  |  | 162d | 1d | start no earlier than 2012-11-23 | lun; seki | 128h |  |
| 17 | 1.1.5 | **OSEM** | 89d? | 2013-10-04 A | 2013-12-31 |  | 17% | 73.57d? | 243d |  |  |  | 1280h | 154h |
| 18 | 1.1.5.1 | OSEM test with Nick's circuit | 41d? | 2013-10-04 A | 2013-11-30 |  | 25% | 30.75d? | 272d |  | finish no earlier than 2013-11-30 | fab | 328h | 82h |
| 19 | 1.1.5.2 | OSEM test with temporary circuit | 12d? | 2013-10-24 A | 2013-11-08 |  | 75% | 3d? | 294d |  | finish no earlier than 2013-11-08 | fab | 96h | 72h |
| 20 | 1.1.5.3 | OSEM temp circuit production | 6d? | 2013-11-05 | 2013-11-10 |  |  |  | 241d | 0d | finish no earlier than 2013-11-10 | ryu | 48h |  |
| 21 | 1.1.5.4 | Calibration bench setup | 16d? | 2013-10-24 | 2013-11-08 |  |  |  | 294d |  | finish no earlier than 2013-11-08 | fab; joris | 192h |  |
| 22 | 1.1.5.5 | OSEM temp calibration | 5d? | 2013-11-11 | 2013-11-15 | 20 |  |  | 241d | 0d | start no earlier than 2013-11-11 | fab; joris; seki | 120h |  |
| 23 | 1.1.5.6 | OSEM Nick's circuit production | 31d? | 2013-12-01 | 2013-12-31 |  |  |  | 243d |  | start no earlier than 2013-12-01 | miya; ryu | 496h |  |
| 24 | 1.1.6 | **Payload Prototype Test** | 63d? | 2013-11-09 | 2014-01-10 |  |  |  | 233d |  |  |  | 848h |  |
| 25 | 1.1.6.1 | Assembling payload | 5d? | 2013-11-16 | 2013-11-20 | 22 |  |  | 243d | 0d | finish no earlier than 2013-11-20 | fab; joris; ryu; seki | 96h |  |
| 26 | 1.1.6.2 | Rough tuning of alignment | 2d? | 2013-11-21 | 2013-11-22 | 25 |  |  | 243d | 0d | start no earlier than 2013-11-21 | fab; joris | 32h |  |
| 27 | 1.1.6.3 | Digital system setup | 9d? | 2013-11-09 | 2013-11-19 |  |  |  | 285d |  | start no earlier than 2013-11-09 | seki; miya | 112h |  |
| 28 | 1.1.6.4 | Preparing LVDT, VoCo, motor driver | 5d? | 2013-11-11 | 2013-11-15 |  |  |  | 287d |  | finish no earlier than 2013-11-15 | ryu; seki | 80h |  |
| 29 | 1.1.6.5 | Operation check of motors | 4d? | 2013-11-23 | 2013-11-26 | 26 |  |  | 243d | 0d | finish no earlier than 2013-11-25 | fab; joris; ryu | 48h |  |
| 30 | 1.1.6.6 | Transfer function measurement | 8d? | 2013-11-27 | 2013-12-04 | 29 |  |  | 243d | 0d | start no earlier than 2013-11-26 | fab; joris | 96h |  |
| 31 | 1.1.6.7 | Control test | 19d? | 2013-12-05 | 2013-12-31 | 30 |  |  | 241d |  | finish no earlier than 2013-12-31 | fab; seki | 304h |  |
| 32 | 1.1.6.8 | Long term observation | 10d? | 2013-12-30 | 2014-01-10 |  |  |  | 231d |  | finish no earlier than 2014-01-10 | seki | 80h |  |

| ID | WBS | Task | Duration | Start | Finish | Predecessors | Complete | Remaining | Total slack | Free slack | Constraint | Resources | Work | Actual work |
| --- | --- | --- | --- | --- | --- | --- | --- | --- | --- | --- | --- | --- | --- | --- |
| 33 | 1.1.7 | **Optical lever** | 110d? | 2013-10-21 A | 2014-02-07 |  | 14% | 94.62d? | 205d |  |  |  | 2000h | 384h |
| 34 | 1.1.7.1 | Pylon design | 33d? | 2013-10-21 A | 2013-11-22 |  | 53% | 15.67d? | 282d |  | finish no earlier than 2013-11-22 | seki; akt; obc | 712h | 384h |
| 35 | 1.1.7.2 | Pylon production | 12d? | 2013-11-25 | 2013-12-06 |  |  |  | 268d |  | finish no earlier than 2013-12-06 | obc | 96h |  |
| 36 | 1.1.7.3 | OL test on optical bench | 20d? | 2013-11-11 | 2013-11-30 |  |  |  | 273d |  | start no earlier than 2013-11-11 | aga; seki | 280h |  |
| 37 | 1.1.7.4 | Pylon test | 25d? | 2013-12-17 | 2014-01-10 |  |  |  | 231d |  | finish no earlier than 2014-01-10 | seki; lun; obc | 496h |  |
| 38 | 1.1.7.5 | OL test in TAMA | 34d? | 2014-01-03 | 2014-02-07 |  |  |  | 203d |  | finish no earlier than 2014-02-07 | seki; akt | 416h |  |
| 39 | 1.1.8 | **Vacuum** | 14d? | 2013-12-18 | 2013-12-31 |  |  |  | 161d | 8d |  |  | 112h |  |
| 40 | 1.1.8.1 | Vacuum test in TAMA | 14d? | 2013-12-18 | 2013-12-31 | 16 |  |  | 161d |  | start no earlier than 2013-12-18 | ryu | 112h |  |
| 41 | 1.1.9 | **Preisolator test in vacuum** | 53d? | 2014-01-07 | 2014-02-28 |  |  |  | 125d | 0d |  |  | 872h |  |
| 42 | 1.1.9.1 | Mechanical system setup | 17d? | 2014-01-09 | 2014-01-31 | 39 |  |  | 153d |  | finish no earlier than 2014-01-31 | fab; seki | 272h |  |
| 43 | 1.1.9.2 | Digital system setup | 19d? | 2014-01-07 | 2014-01-31 |  |  |  | 153d |  | finish no earlier than 2014-01-31 | seki | 152h |  |
| 44 | 1.1.9.3 | Control test in vacuum | 28d? | 2014-01-22 | 2014-02-28 |  |  |  | 125d |  | finish no earlier than 2014-02-28 | fab; seki | 448h |  |
| 45 | 1.1.10 | **Type-B test with fixed payload** | 92d? | 2014-03-01 | 2014-05-31 |  |  |  | 73d | 0d |  |  | 2336h |  |
| 46 | 1.1.10.1 | Installation, cabling | 36d? | 2014-03-01 | 2014-04-09 | 41 |  |  | 125d |  | start no earlier than 2014-03-01 | fab; ono; ryu; seki | 896h |  |
| 47 | 1.1.10.2 | Preisolator control test | 20d? | 2014-03-26 | 2014-04-16 |  |  |  | 118d |  | finish no earlier than 2014-04-16 | fab; ono; seki | 384h |  |
| 48 | 1.1.10.3 | Optical lever working test | 26d? | 2014-03-20 | 2014-04-16 |  |  |  | 118d |  | finish no earlier than 2014-04-16 | seki; akt | 320h |  |
| 49 | 1.1.10.4 | Torsion mode damping test | 60d? | 2014-03-28 | 2014-05-31 |  |  |  | 73d |  | finish no earlier than 2014-05-31 | fab; ono | 736h |  |
| 50 | 1.1.11 | **Full Type-B test** | 92d? | 2014-06-01 | 2014-08-31 |  |  |  | 0d |  |  |  | 1920h |  |
| 51 | 1.1.11.1 | Release payload | 16d? | 2014-06-01 | 2014-06-18 | 45 |  |  | 73d |  | finish no earlier than 2014-06-13 | fab; ryu; seki | 312h |  |
| 52 | 1.1.11.2 | Operation check of motors | 5d? | 2014-06-16 | 2014-06-20 |  |  |  | 70d |  | finish no earlier than 2014-06-20 | fab; seki | 80h |  |
| 53 | 1.1.11.3 | Mechanical TF measurement | 32d? | 2014-06-11 | 2014-07-15 |  |  |  | 47d |  | finish no earlier than 2014-07-15 | ono; seki | 400h |  |
| 54 | 1.1.11.4 | Full control test | 37d? | 2014-07-04 | 2014-08-13 |  |  |  | 18d |  | finish no earlier than 2014-08-13 | fab; ono; seki | 696h |  |
| 55 | 1.1.11.5 | Long term observation | 23d? | 2014-08-06 | 2014-08-31 |  |  |  | 0d |  | finish no earlier than 2014-08-31 | fab; ono; seki | 432h |  |
